# Сопроводительный файл

How a schedule from MS Project changed from version to version. A marks actual dates.

## Version 1 (data date 2002-02-10, saved 2002-08-22, file 2.MPP)

| ID | WBS | Task | Duration | Start | Finish | Predecessors | Complete | Total float | Constraint |
| --- | --- | --- | --- | --- | --- | --- | --- | --- | --- |
| 1 | PUBL | **Подготовка номера журнала к изданию** | 69.83d | 2002-01-10 A | 2002-04-17 |  | 22% | 0d |  |
| 2 | PUBLAAA | **Планирование номера** | 13d | 2002-01-10 A | 2002-01-28 A |  | 100% |  |  |
| 3 |  | Сбор предложений от авторов | 5d | 2002-01-10 A | 2002-01-16 A |  | 100% |  | start no earlier than 2002-01-07 |
| 4 |  | Подготовка плана номера | 3d | 2002-01-17 A | 2002-01-21 A | 3 | 100% |  |  |
| 5 |  | Предварительная редколлегия | 1d | 2002-01-22 A | 2002-01-22 A | 4 | 100% |  |  |
| 6 |  | Доработка планов с учетом замечаний | 3d | 2002-01-23 A | 2002-01-25 A | 5 | 100% |  |  |
| 7 |  | Редколлегия | 1d | 2002-01-28 A | 2002-01-28 A | 6 | 100% |  |  |
| 8 |  | План номера утвержден | 0d | 2002-01-28 A | 2002-01-28 A | 7 | 100% |  |  |
| 9 | PUBLAAB | **Подготовка текстов** | 34.33d | 2002-01-29 A | 2002-03-18 |  | 23% | 19.5d |  |
| 10 |  | Подготовка редакционных заданий | 3d | 2002-01-29 A | 2002-01-31 A | 8 | 100% |  |  |
| 11 |  | Рассылка заданий авторам | 2d | 2002-02-01 A | 2002-02-04 A | 10 | 100% |  |  |
| 12 |  | Утверждение заданий | 3.33d | 2002-02-05 A | 2002-02-08 A | 11 | 100% |  |  |
| 13 |  | Статьи в работе у авторов | 0d | 2002-02-08 A | 2002-02-08 A | 12 | 100% |  |  |
| 14 |  | Статьи поступили в редакцию | 0d | 2002-02-22 | 2002-02-22 | 13FS+10d |  | 0d |  |
| 15 |  | Редактирование материалов | 14.62d | 2002-02-22 | 2002-03-14 | 14 |  | 0d |  |
| 16 |  | Техническое редактирование | 14d | 2002-02-26 | 2002-03-18 | 15SS+2d |  | 0d |  |
| 17 |  | Подготовка текстов завершена | 0d | 2002-03-18 | 2002-03-18 | 16 |  | 19.5d |  |
| 18 | PUBLAAC | **Верстка журнала** | 44.96d | 2002-01-29 A | 2002-04-01 |  | 16% | 11.88d |  |
| 19 | PUBLAAC-1 | **Подготовка обложки** | 37.33d | 2002-01-29 A | 2002-03-21 | 8 | 60% | 19.5d |  |
| 20 |  | Кастинг для выбора фотомодели | 5d | 2002-01-29 A | 2002-02-04 A |  | 100% |  |  |
| 21 |  | Фотосъемка модели | 4d | 2002-02-05 A | 2002-02-08 A | 20 | 100% |  |  |
| 22 |  | Подготовка макета обложки | 3d | 2002-02-11 | 2002-02-13 | 21 |  | 41.83d |  |
| 23 |  | Подготовка анонсов материалов номера для обложки | 3d | 2002-03-18 | 2002-03-21 | 17, 22 |  | 19.5d |  |
| 24 |  | Обложка готова | 0d | 2002-03-21 | 2002-03-21 | 23 |  | 19.5d |  |
| 25 |  | Обработка текста и иллюстраций | 14d | 2002-03-01 | 2002-03-21 | 16SS+3d |  | 0d |  |
| 26 |  | Вычитка | 14d | 2002-03-06 | 2002-03-26 | 25SS+3d |  | 13.88d |  |
| 27 |  | Сверка | 12d | 2002-03-14 | 2002-04-01 | 26SS+3d |  | 11.88d |  |
| 28 |  | Подготовка оглавления | 2d | 2002-03-21 | 2002-03-25 | 25 |  | 0d |  |
| 29 |  | Номер сверстан | 0d | 2002-03-25 | 2002-03-25 | 28 |  | 0d |  |
| 30 | PUBLAAD | **Предпечатная подготовка** | 17.5d | 2002-03-25 | 2002-04-17 |  |  | 0d |  |
| 31 |  | Конвертция сверстанного номера в формат Mac | 7.5d | 2002-03-25 | 2002-04-03 | 29 |  | 0d |  |
| 32 |  | Цветоделение | 7d | 2002-04-03 | 2002-04-12 | 31 |  | 0d |  |
| 33 |  | Коррекция | 7d | 2002-04-04 | 2002-04-15 | 32SS+1d |  | 0d |  |
| 34 |  | Вывод пленок | 7d | 2002-04-08 | 2002-04-17 | 33SS+2d |  | 0d |  |
| 35 |  | Номер готов к передаче в типографию | 0d | 2002-04-17 | 2002-04-17 | 34 |  | 0d |  |

## Version 2 (data date 2002-02-10, saved 2002-08-22, file 5.MPP)

Last finish stays 2002-04-17. Complete tasks 12 → 2.

Changed:

| ID | Task | Start | Finish | Complete | Total float |
| --- | --- | --- | --- | --- | --- |
| 1 | **Подготовка номера журнала к изданию** |  |  | 22% → 0% |  |
| 2 | **Планирование номера** |  | 2002-01-28 A → 2002-01-28 | 100% → 0% | none → 56.83d |
| 3 | Сбор предложений от авторов |  | 2002-01-16 A → 2002-01-16 | 100% → 0% | none → 56.83d |
| 4 | Подготовка плана номера | 2002-01-17 A → 2002-01-17 | 2002-01-21 A → 2002-01-21 | 100% → 0% | none → 56.83d |
| 5 | Предварительная редколлегия | 2002-01-22 A → 2002-01-22 | 2002-01-22 A → 2002-01-22 | 100% → 0% | none → 56.83d |
| 6 | Доработка планов с учетом замечаний | 2002-01-23 A → 2002-01-23 | 2002-01-25 A → 2002-01-25 | 100% → 0% | none → 56.83d |
| 7 | Редколлегия | 2002-01-28 A → 2002-01-28 | 2002-01-28 A → 2002-01-28 | 100% → 0% | none → 56.83d |
| 9 | **Подготовка текстов** |  |  | 23% → 0% | 19.5d → 22.5d |
| 10 | Подготовка редакционных заданий | 2002-01-29 A → 2002-01-29 | 2002-01-31 A → 2002-01-31 | 100% → 0% | none → 0d |
| 11 | Рассылка заданий авторам | 2002-02-01 A → 2002-02-01 | 2002-02-04 A → 2002-02-04 | 100% → 0% | none → 0d |
| 12 | Утверждение заданий |  | 2002-02-08 A → 2002-02-08 | 100% → 0% | none → 48.5d |
| 18 | **Верстка журнала** | 2002-01-29 A → 2002-01-29 |  | 16% → 0% |  |
| 19 | **Подготовка обложки** | 2002-01-29 A → 2002-01-29 |  | 60% → 0% |  |
| 20 | Кастинг для выбора фотомодели | 2002-01-29 A → 2002-01-29 | 2002-02-04 A → 2002-02-04 | 100% → 0% | none → 41.83d |
| 21 | Фотосъемка модели | 2002-02-05 A → 2002-02-05 | 2002-02-08 A → 2002-02-08 | 100% → 0% | none → 41.83d |

## Version 3 (data date 2002-02-10, saved 2002-08-22, file 3.MPP)

Last finish stays 2002-04-17. Complete tasks 2 → 12.

Changed:

| ID | Task | Start | Finish | Complete | Total float |
| --- | --- | --- | --- | --- | --- |
| 1 | **Подготовка номера журнала к изданию** |  |  | 0% → 22% |  |
| 2 | **Планирование номера** |  | 2002-01-28 A | 0% → 100% | 56.83d → none |
| 3 | Сбор предложений от авторов |  | 2002-01-16 A | 0% → 100% | 56.83d → none |
| 4 | Подготовка плана номера | 2002-01-17 A | 2002-01-21 A | 0% → 100% | 56.83d → none |
| 5 | Предварительная редколлегия | 2002-01-22 A | 2002-01-22 A | 0% → 100% | 56.83d → none |
| 6 | Доработка планов с учетом замечаний | 2002-01-23 A | 2002-01-25 A | 0% → 100% | 56.83d → none |
| 7 | Редколлегия | 2002-01-28 A | 2002-01-28 A | 0% → 100% | 56.83d → none |
| 9 | **Подготовка текстов** |  |  | 0% → 23% | 22.5d → 19.5d |
| 10 | Подготовка редакционных заданий | 2002-01-29 A | 2002-01-31 A | 0% → 100% | 0d → none |
| 11 | Рассылка заданий авторам | 2002-02-01 A | 2002-02-04 A | 0% → 100% | 0d → none |
| 12 | Утверждение заданий |  | 2002-02-08 A | 0% → 100% | 48.5d → none |
| 18 | **Верстка журнала** | 2002-01-29 A |  | 0% → 16% |  |
| 19 | **Подготовка обложки** | 2002-01-29 A |  | 0% → 60% |  |
| 20 | Кастинг для выбора фотомодели | 2002-01-29 A | 2002-02-04 A | 0% → 100% | 41.83d → none |
| 21 | Фотосъемка модели | 2002-02-05 A | 2002-02-08 A | 0% → 100% | 41.83d → none |
